Schedule from MS Project, 2018-01-11 to 2018-05-25, A marks actual dates.
Microsoft

## Calendars

- ProjetAIES2018: Mon-Tue off; Wed 14:00-18:00; Thu 09:00-12:00, 15:00-18:00; Fri 14:00-17:00; Sat-Sun off. Exceptions (off unless hours are given): 2018-02-22 (BTS Blanc 1), 2018-02-24 to 2018-03-11 (Vacances de février), 2018-03-19 09:00-12:00, 14:00-18:00, 2018-04-19 (BTS Blanc 2), 2018-04-21 to 2018-05-06 (Vacances de printemps), 2018-05-08 (Férié : Victoire 1945), 2018-05-14 09:00-12:00, 14:00-18:00.

## Resources

| Resource |
| --- |
| BOTTIGLIERO Nicolas |
| BUFFE Jordan |
| BUSSERET Dylan |
| CARRILLO Thomas |
| DEMONCHY Maxime |
| LOZANO Dorian |
| TISON Sylvain |

## Schedule

| ID | WBS | Task | Duration | Start | Finish | Predecessors | Complete | Remaining | Total slack | Free slack | Constraint | Resources | Work | Actual work |
| --- | --- | --- | --- | --- | --- | --- | --- | --- | --- | --- | --- | --- | --- | --- |
| 1 | 1 | **Projet** | 204h | 2018-01-11 A | 2018-05-25 |  | 4% | 195.84h |  |  |  | BOTTIGLIERO Nicolas; BUFFE Jordan; BUSSERET Dylan; CARRILLO Thomas; DEMONCHY Maxime; LOZANO Dorian; TISON Sylvain | 2846h | 167.34h |
| 2 | 1.1 | **Tâches communes** | 10h | 2018-01-11 A | 2018-01-17 A |  | 100% |  |  |  |  | BOTTIGLIERO Nicolas; BUFFE Jordan; BUSSERET Dylan; CARRILLO Thomas; DEMONCHY Maxime; LOZANO Dorian; TISON Sylvain | 70h | 70h |
| 3 | 1.1.1 | Lecture du dossier | 2h | 2018-01-11 A | 2018-01-11 A |  | 100% |  |  |  |  |  |  |  |
| 4 | 1.1.2 | Analyse de l'existant | 1h | 2018-01-11 A | 2018-01-11 A | 3 | 100% |  |  |  |  |  |  |  |
| 5 | 1.1.3 | Réunion de synthèse | 1h | 2018-01-11 A | 2018-01-11 A | 4 | 100% |  |  |  |  |  |  |  |
| 6 | 1.1.4 | Réaliser un plan des itérations | 2h | 2018-01-11 A | 2018-01-11 A | 5 | 100% |  |  |  |  |  |  |  |
| 7 | 1.1.5 | Réaliser un planning prévisionnel | 4h | 2018-01-11 A | 2018-01-17 A | 6 | 100% |  |  |  | finish no earlier than 2018-01-11 |  |  |  |
| 8 | 1.2 | **Tâches Demonchy** | 204h | 2018-01-11 A | 2018-05-25 |  | 21% | 160.78h |  |  |  | DEMONCHY Maxime | 204h | 40.25h |
| 9 | 1.2.1 | Recherche | 20h | 2018-01-18 A | 2018-01-26 | 7 | 55% | 9h | 2.28d | 0d |  |  |  |  |
| 10 | 1.2.2 | Mise en œuvre de plusieurs threads multithread | 50h | 2018-01-24 A | 2018-02-16 | 9 | 59% | 20.75h | 1.5d | 0d |  |  |  |  |
| 11 | 1.2.3 | Mise en oeuvre d'une communication entre processus par messages | 40h | 2018-02-16 | 2018-03-23 | 10 |  |  | 1.5d | 0d | start no earlier than 2018-02-14 |  |  |  |
| 12 | 1.2.4 | Mise en oeuvre d'une zone mémoire commune accessible par tous les threads. | 20h | 2018-03-23 | 2018-04-05 | 11 |  |  | 1.5d | 0d | start no earlier than 2018-02-23 |  |  |  |
| 13 | 1.2.5 | Codage de gérer la mission | 10h | 2018-04-05 | 2018-04-11 | 12 |  |  | 1.5d | 0d |  |  |  |  |
| 14 | 1.2.6 | Intégration dans le projet final | 10h | 2018-04-11 | 2018-04-13 | 13 |  |  | 1.5d | 0d |  |  |  |  |
| 15 | 1.2.7 | Sauvegarde des mesures dans un fichier local | 30h | 2018-04-13 | 2018-05-16 | 14 |  |  | 1.5d | 1.38d |  |  |  |  |
| 16 | 1.2.8 | Réalisation du dossier, codage et tests unitaires | 10h | 2018-05-23 | 2018-05-24 | 15 |  |  | 0.12d |  | start no earlier than 2018-05-23 |  |  |  |
| 17 | 1.3 | **Tâches Busseret** | 204h | 2018-01-11 | 2018-05-25 |  |  |  |  |  |  | BUSSERET Dylan | 204h |  |
| 18 | 1.3.1 | Recherche | 20h | 2018-01-18 | 2018-01-26 | 7 |  |  | 0.12d | 0d | start no earlier than 2018-01-18 |  |  |  |
| 19 | 1.3.2 | Codage de l'IHM et préparer, superviser la mission | 50h | 2018-01-26 | 2018-03-14 | 18 |  |  | 0.12d | 0d |  |  |  |  |
| 20 | 1.3.3 | IHM dédiée au développement et débogage | 40h | 2018-03-14 | 2018-03-29 | 19 |  |  | 0.12d | 0d |  |  |  |  |
| 21 | 1.3.4 | Conception de la base de données | 40h | 2018-03-29 | 2018-05-09 | 20 |  |  | 0.12d | 0d |  |  |  |  |
| 22 | 1.3.5 | Création d'une classe de gestion de la BDD | 20h | 2018-05-09 | 2018-05-16 | 21 |  |  | 0.12d | 0d |  |  |  |  |
| 23 | 1.3.6 | Réalisation du dossier, codage et tests unitaires | 10h | 2018-05-16 | 2018-05-18 | 22 |  |  | 0.12d | 0d |  |  |  |  |
| 24 | 1.3.7 | Cahier de procédures en cas de défaillance | 10h | 2018-05-23 | 2018-05-24 | 23 |  |  | 0.12d |  |  |  |  |  |

| ID | WBS | Task | Duration | Start | Finish | Predecessors | Total slack | Free slack | Constraint | Resources | Work |
| --- | --- | --- | --- | --- | --- | --- | --- | --- | --- | --- | --- |
| 25 | 1.4 | **Tâches Carrillo** | 204h | 2018-01-11 | 2018-05-25 |  |  |  |  | CARRILLO Thomas | 204h |
| 26 | 1.4.1 | Recherche | 20h | 2018-01-18 | 2018-01-26 | 7 | 0.12d | 0d | start no earlier than 2018-01-18 |  |  |
| 27 | 1.4.2 | codage de la communication DATA (et envoi des mesures) | 50h | 2018-01-26 | 2018-03-14 | 26 | 0.12d | 0d |  |  |  |
| 28 | 1.4.3 | Cryptage des échanges | 10h | 2018-03-14 | 2018-03-16 | 27 | 0.12d | 0d |  |  |  |
| 29 | 1.4.4 | Mise en oeuvre de la communication par liaison radio | 30h | 2018-03-16 | 2018-03-29 | 28 | 0.12d | 0d |  |  |  |
| 30 | 1.4.5 | Analyse et codage du protocole DATA | 60h | 2018-03-29 | 2018-05-16 | 29 | 0.12d | 0d |  |  |  |
| 31 | 1.4.6 | Intégration du CRC et cryptage dans les échanges radio | 10h | 2018-05-16 | 2018-05-18 | 30 | 0.12d | 0d |  |  |  |
| 32 | 1.4.7 | Réalisation du dossier, codage et tests unitaires | 10h | 2018-05-23 | 2018-05-24 | 31 | 0.12d |  |  |  |  |
| 33 | 1.5 | **Tâches Buffe** | 184h | 2018-01-11 | 2018-05-16 |  |  |  |  | BUFFE Jordan | 184h |
| 34 | 1.5.1 | Recherche documentation + solution de l'année précédente | 20h | 2018-01-11 | 2018-01-19 |  | 4d | 0d | finish no earlier than 2018-01-19 |  |  |
| 35 | 1.5.2 | Diagramme de blocs et de séquence | 10h | 2018-01-24 | 2018-01-25 | 34 | 4d | 0.38d |  |  |  |
| 36 | 1.5.3 | Test du capteurs sur Arduino et Raspberry | 10h | 2018-01-31 | 2018-02-01 | 35 | 3.62d | 0d | start no earlier than 2018-01-31 |  |  |
| 37 | 1.5.4 | Codage | 30h | 2018-02-02 | 2018-02-21 | 36 | 3.62d | 0.75d |  |  |  |
| 38 | 1.5.5 | Realisation de la carte alimentation | 40h | 2018-03-14 | 2018-03-29 | 37 | 2.88d | 0.38d | start no earlier than 2018-03-14 |  |  |
| 39 | 1.5.6 | Mise en place | 20h | 2018-03-30 | 2018-04-11 | 38 | 2.5d | 0d | finish no earlier than 2018-04-11 |  |  |
| 40 | 1.5.7 | Routage | 20h | 2018-04-12 | 2018-05-09 | 39 | 2.5d | 0d | start no earlier than 2018-04-11 |  |  |
| 41 | 1.5.8 | Finalisation | 20h | 2018-05-10 | 2018-05-16 | 40 | 2.5d |  | start no earlier than 2018-05-09 |  |  |
| 42 | 1.6 | **Tâches Bottigliero** | 184h | 2018-01-11 | 2018-05-16 |  |  |  |  | BOTTIGLIERO Nicolas | 184h |
| 43 | 1.6.1 | Recherche documentation + solution de l'année précédente | 20h | 2018-01-11 | 2018-01-19 |  | 4d | 0d | finish no earlier than 2018-01-19 |  |  |
| 44 | 1.6.2 | Diagramme de blocs et de séquence | 10h | 2018-01-24 | 2018-01-25 | 43 | 4d | 0.38d | finish no earlier than 2018-01-24 |  |  |
| 45 | 1.6.3 | Test du capteurs sur Arduino et Raspberry | 10h | 2018-01-31 | 2018-02-01 | 44 | 3.62d | 0d | start no earlier than 2018-01-31 |  |  |
| 46 | 1.6.4 | Codage | 30h | 2018-02-02 | 2018-02-21 | 45 | 3.62d | 0.75d | start no earlier than 2018-02-02 |  |  |
| 47 | 1.6.5 | Realisation de la carte alimentation | 40h | 2018-03-14 | 2018-03-29 | 46 | 2.88d | 0.38d | start no earlier than 2018-03-14 |  |  |
| 48 | 1.6.6 | Mise en place | 20h | 2018-03-30 | 2018-04-11 | 47 | 2.5d | 0d | finish no earlier than 2018-04-11 |  |  |
| 49 | 1.6.7 | Routage | 20h | 2018-04-12 | 2018-05-09 | 48 | 2.5d | 0d | finish no earlier than 2018-05-09 |  |  |
| 50 | 1.6.8 | Finalisation | 20h | 2018-05-10 | 2018-05-16 | 49 | 2.5d |  | finish no earlier than 2018-05-16 |  |  |

| ID | WBS | Task | Type | Duration | Start | Finish | Predecessors | Total slack | Free slack | Constraint | Resources | Work |
| --- | --- | --- | --- | --- | --- | --- | --- | --- | --- | --- | --- | --- |
| 51 | 1.7 | **Tâches Lozano** |  | 184h | 2018-01-11 | 2018-05-16 |  |  |  |  | LOZANO Dorian | 184h |
| 52 | 1.7.1 | Recherche documentation + solution de l'année précédente |  | 20h | 2018-01-11 | 2018-01-19 |  | 4.25d | 0.25d |  |  |  |
| 53 | 1.7.2 | Diagramme de blocs et de séquence |  | 10h | 2018-01-24 | 2018-01-25 | 52 | 4d | 0.38d | start no earlier than 2018-01-24 |  |  |
| 54 | 1.7.3 | Test du capteurs sur Arduino et Raspberry |  | 10h | 2018-01-31 | 2018-02-01 | 53 | 3.62d | 0d | start no earlier than 2018-01-31 |  |  |
| 55 | 1.7.4 | Codage |  | 30h | 2018-02-02 | 2018-02-21 | 54 | 3.62d | 0.75d |  |  |  |
| 56 | 1.7.5 | Realisation de la carte alimentation |  | 40h | 2018-03-14 | 2018-03-29 | 55 | 2.88d | 0d | start no earlier than 2018-03-14 |  |  |
| 57 | 1.7.6 | Mise en place |  | 20h | 2018-03-29 | 2018-04-11 | 56 | 2.88d | 0d | start no earlier than 2018-03-22 |  |  |
| 58 | 1.7.7 | Routage |  | 20h | 2018-04-11 | 2018-05-09 | 57 | 2.88d | 0.38d | finish no earlier than 2018-04-18 |  |  |
| 59 | 1.7.8 | Finalisation |  | 20h | 2018-05-10 | 2018-05-16 | 58 | 2.5d |  | finish no earlier than 2018-05-16 |  |  |
| 60 | 1.8 | **Tâches Tison** |  | 184h | 2018-01-11 | 2018-05-16 |  |  |  |  | TISON Sylvain | 184h |
| 61 | 1.8.1 | Recherche documentation + solution de l'année précédente |  | 20h | 2018-01-11 | 2018-01-19 |  | 4.38d | 0d | finish no earlier than 2018-01-19 |  |  |
| 62 | 1.8.2 | Diagramme de blocs et de séquence |  | 10h | 2018-01-24 | 2018-01-25 | 61 | 4.38d | 0d | finish no earlier than 2018-01-25 |  |  |
| 63 | 1.8.3 | Test du capteurs sur Arduino et Raspberry |  | 10h | 2018-01-26 | 2018-02-01 | 62 | 4.38d | 0.38d | start no earlier than 2018-01-26 |  |  |
| 64 | 1.8.4 | Codage |  | 30h | 2018-02-02 | 2018-02-21 | 63 | 4d | 1.12d | start no earlier than 2018-02-02 |  |  |
| 65 | 1.8.5 | Realisation de la carte alimentation |  | 40h | 2018-03-14 | 2018-03-29 | 64 | 2.88d | 0d | finish no earlier than 2018-03-29 |  |  |
| 66 | 1.8.6 | Mise en place |  | 20h | 2018-03-30 | 2018-04-11 | 65 | 2.88d | 0d | finish no earlier than 2018-04-11 |  |  |
| 67 | 1.8.7 | Routage |  | 20h | 2018-04-12 | 2018-05-09 | 66 | 2.88d | 0.38d | finish no earlier than 2018-05-09 |  |  |
| 68 | 1.8.8 | Finalisation |  | 17h | 2018-05-10 | 2018-05-16 | 67 | 2.5d |  | finish no earlier than 2018-05-16 |  |  |
| 70 | 2 | Revue 1 | milestone | 0h | 2018-03-19 | 2018-03-19 |  | 13.75d |  | start no earlier than 2018-03-19 |  |  |
| 71 | 3 | Revue 2 | milestone | 0h | 2018-05-14 | 2018-05-14 |  | 3.88d |  | start no earlier than 2018-05-14 |  |  |
| 72 | 4 | Revue finale | milestone | 0h | 2018-05-25 | 2018-05-25 |  | 0.12d |  | start no earlier than 2018-05-25 |  |  |
